# CLAS 12GeV Design and Engineering Schedule Sep 18 2012

Schedule from MS Project, 2012-09-17 to 2013-10-07.
Jefferson Science Associates, LLC

## Calendars

- Standard: Mon-Fri 08:00-12:00, 13:00-17:00; Sat-Sun off.

## Resources

| Resource |
| --- |
| Brandon |
| Forrest |
| Allen |
| Cyril |
| Joe |

## Schedule

| ID | WBS | Task | Type | Duration | Start | Finish | Predecessors | Total slack | Free slack | Deadline | Resources | Work | Activity ID |
| --- | --- | --- | --- | --- | --- | --- | --- | --- | --- | --- | --- | --- | --- |
| 1 | 1 | SVT | manual | 1d? | 2012-09-17 | 2012-09-17 |  |  |  |  |  |  |  |
| 2 | 2 | Tooling to rotate SVT from vertical assembly stand to horizontal |  | 3w | 2013-06-11 | 2013-07-01 | 22 | -226d | 0d | 2012-08-31 | Brandon | 120h | 142211255 |
| 3 | 3 | Cart to move SVT to DC cleanroom |  | 2w | 2013-07-02 | 2013-07-15 | 2 | -226d | 0d | 2012-08-31 | Brandon | 80h | 142211255 |
| 4 | 4 | Tooling to join SVT and MM | manual | 6w | 2013-02-25 | 2013-04-05 | 8 |  |  | 2012-08-31 | Forrest | 240h | 142211255 |
| 5 | 5 | Design external cooling system |  | 5w | 2013-01-29 | 2013-03-04 | 6 | -255d | 0d | 2012-03-12 | Brandon | 200h | 142211450 |
| 6 | 6 | Detector component and assembly drawings |  | 96d | 2012-09-17 | 2013-01-28 |  | -255d | 0d | 2013-01-28 | Brandon | 768h | 142211465 |
| 7 | 7 | Design and drawings R4 mechanical |  | 12w | 2013-07-16 | 2013-10-07 | 3 | 0d |  | 2014-02-15 | Brandon | 480h | 142211545 |
| 8 | 8 | Support tube for SVT / MM |  | 3w | 2013-02-04 | 2013-02-22 | 65 | 0d |  | 2013-03-29 | Forrest | 120h | 142211800 |
| 9 | 9 | Mounts for SVT/MM to solenoid |  | 4w | 2013-04-08 | 2013-05-03 | 4 | 0d |  | 2014-04-18 | Forrest | 160h | 142211820 |
| 10 | 10 | Insertion cart | manual | 5w | 2013-05-06 | 2013-06-07 | 9 |  |  | 2013-03-29 | Forrest | 200h | 142211840 |
| 11 | 11 | Transport cart for SVT and MM |  | 12w | 2013-06-10 | 2013-08-30 | 10 | -172d | 0d | 2013-01-02 | Forrest | 480h | 142211875 |
| 13 | 12 | Drift Chambers | manual | 1d? | 2012-09-17 | 2012-09-17 |  |  |  |  |  |  |  |
| 14 | 13 | Load test installation tooling | manual | 1d | 2012-09-17 | 2012-09-17 |  |  |  |  |  |  |  |
| 15 | 14 | HV cable strain relief at top of chambers and cable bundle on strongback |  | 3w | 2012-10-08 | 2012-10-26 | 41 | -96d | 0d | 2012-12-15 | Allen | 120h |  |
| 16 | 15 | Mounts and adjusters to Torus |  | 6w | 2012-10-29 | 2012-12-07 | 15 | -96d | 0d | 2014-03-31 | Allen | 240h |  |
| 17 | 16 | Cable trays and gas system mounts |  | 12w | 2012-12-10 | 2013-03-01 | 16 | -96d | 0d | 2013-12-15 | Allen | 480h |  |
| 18 | 17 | Maintenance platforms |  | 6w | 2013-03-04 | 2013-04-12 | 17 | -96d | 0d | 2013-12-15 | Allen | 240h |  |
| 20 | 18 | PCAL | manual | 1d? | 2012-09-17 | 2012-09-17 |  |  |  |  |  |  |  |
| 21 | 19 | Hall ramp cradle |  | 5w | 2013-03-05 | 2013-04-08 | 5 | -226d | 0d | 2013-09-27 | Brandon | 200h |  |
| 22 | 20 | Installation tooling |  | 9w | 2013-04-09 | 2013-06-10 | 21 | -226d | 0d | 2013-09-27 | Brandon | 360h |  |
| 24 | 21 | CTOF | manual | 1d? | 2012-09-17 | 2012-09-17 |  |  |  |  |  |  |  |
| 25 | 22 | Final drawings for tooling for wrapping | manual | 6w | 2012-09-17 | 2012-10-26 |  |  |  | 2012-03-26 | Cyril | 240h | 142231140 |
| 26 | 23 | Final drawings for counter storage | manual | 3w | 2012-10-29 | 2012-11-16 | 25 |  |  | 2012-03-09 | Cyril | 120h | 142231235 |
| 27 | 24 | Final drawings for CTOF support and Solenoid Harness | manual | 12w | 2012-11-19 | 2013-02-08 | 26 |  |  | 2012-06-15 | Cyril | 480h | 142231260 |
| 28 | 25 | Final drawings for counter installation arm - cart | manual | 12w | 2013-02-11 | 2013-05-03 | 27 |  |  | 2012-09-13 | Cyril | 480h | 142231270 |
| 29 | 26 | Final drawings for magnetic shield compensating coil | manual | 2w | 2013-05-06 | 2013-05-17 | 28 |  |  | 2012-06-16 | Cyril | 80h | 142231280 |
| 30 | 27 | Final drawings for magnetic shield components | manual | 8w | 2013-05-20 | 2013-07-12 | 29 |  |  | 2012-05-01 | Cyril | 320h | 142231285 |
| 31 | 28 | Transport rack | manual | 6w | 2013-07-15 | 2013-08-23 | 30 |  |  | 2014-02-10 | Cyril | 240h |  |
| 32 | 29 | Final drawings for patch panels for LV & HV; 200 ch | manual | 1w | 2013-08-26 | 2013-08-30 | 31 |  |  | 2012-05-23 | Cyril | 40h | 142231345 |
| 33 | 30 | Final drawings for splitter to TDC and ADC; 100 ch | manual | 1w | 2013-09-02 | 2013-09-06 | 32 |  |  | 2012-05-23 | Cyril | 40h | 142231350 |
| 35 | 31 | FTOF | manual | 1d? | 2012-09-17 | 2012-09-17 |  |  |  |  |  |  |  |
| 36 | 32 | 1B frame and mounts |  | 3w | 2012-09-17 | 2012-10-05 |  | -537d | 0d | 2010-09-15 | Joe | 120h | 142232350 |
| 37 | 33 | Strongback mods |  | 2w | 2012-10-08 | 2012-10-19 | 36 | -109d | 0d | 2013-10-30 | Joe | 80h | 14264130 |
| 38 | 34 | 1B counter shipping containers and storage racks |  | 2w | 2012-10-22 | 2012-11-02 | 37 | -109d | 0d | 2013-05-30 | Joe | 80h |  |
| 40 | 35 | HTCC | manual | 1d? | 2012-09-17 | 2012-09-17 |  |  |  |  |  |  |  |
| 41 | 36 | Containment vessel design |  | 3w | 2012-09-17 | 2012-10-05 |  | -96d | 0d | 2013-07-03 | Allen | 120h | 142241450b |
| 42 | 37 | Entry dish layout patterns |  | 1w | 2013-04-15 | 2013-04-19 | 18 | -96d | 0d | 2013-09-03 | Allen | 40h |  |
| 43 | 38 | Transport cart |  | 4w | 2013-04-22 | 2013-05-17 | 42 | -96d | 0d | 2013-01-31 | Allen | 160h | 14264105 |
| 44 | 39 | Support cart |  | 4w | 2013-05-20 | 2013-06-14 | 43 | -96d | 0d | 2013-01-31 | Allen | 160h | 14264105 |
| 46 | 40 | LTCC | manual | 1d? | 2012-09-17 | 2012-09-17 |  |  |  |  |  |  |  |
| 47 | 41 | Mirror sag test |  | 2w | 2012-11-05 | 2012-11-16 | 38 | -109d | 0d | 2013-02-07 | Joe | 80h | 142242035 |
| 48 | 42 | Box mods |  | 12w | 2012-11-19 | 2013-02-08 | 47 | -109d | 0d | 2013-04-02 | Joe | 480h | 142242145 |
| 49 | 43 | Window design |  | 3w | 2013-02-11 | 2013-03-01 | 48 | -109d | 0d | 2013-04-02 | Joe | 120h | 142242135 |
| 50 | 44 | Tooling mods |  | 3w | 2013-03-04 | 2013-03-22 | 49 | -109d | 0d | 2014-03-19 | Joe | 120h |  |
| 52 | 45 | Beamline | manual | 1d? | 2012-09-17 | 2012-09-17 |  |  |  |  |  |  |  |
| 53 | 46 | Beamline drawing |  | 3w | 2013-04-22 | 2013-05-10 | 56 | -109d | 0d | 2013-02-04 | Joe | 120h | 14264019M |
| 54 | 47 | Stands for beamline components |  | 6w | 2013-05-27 | 2013-07-05 | 57 | -109d | 0d | 2013-02-04 | Joe | 240h | 14264020 |
| 55 | 48 | Apex extension for PCAL |  | 2w | 2013-03-25 | 2013-04-05 | 50 | -109d | 0d | 2013-04-25 | Joe | 80h | 14264016 |
| 56 | 49 | Lead nose on FC |  | 2w | 2013-04-08 | 2013-04-19 | 55 | -109d | 0d | 2013-04-25 | Joe | 80h | 14264016 |
| 57 | 50 | Moeller shield |  | 2w | 2013-05-13 | 2013-05-24 | 53 | -109d | 0d | 2014-06-15 | Joe | 80h |  |
| 58 | 51 | Forward tagger integration |  | 3w | 2013-07-08 | 2013-07-26 | 54 | 21d | 0d |  | Joe | 120h |  |
| 59 | 52 | Forward tagger spoolpiece |  | 2w | 2013-07-29 | 2013-08-09 | 58 | 21d | 0d | 2014-06-15 | Joe | 80h |  |
| 60 | 53 | Integrate central detector |  | 4w | 2013-08-12 | 2013-09-06 | 59 | 21d |  |  | Joe | 160h |  |
| 62 | 54 | Subway | manual | 1d? | 2012-09-17 | 2012-09-17 |  |  |  |  |  |  |  |
| 63 | 55 | Install and align subway rail |  | 2w | 2012-12-03 | 2012-12-14 | 68 | 0d |  | 2013-03-29 | Forrest | 80h | 14264008 |
| 64 | 56 | Solenoid motion system |  | 5w | 2012-12-17 | 2013-01-18 | 63 | 0d |  | 2014-04-07 | Forrest | 200h | 14264008a |
| 65 | 57 | Solenoid heater system |  | 2w | 2013-01-21 | 2013-02-01 | 64 | 0d |  | 2014-06-26 | Forrest | 80h |  |
| 67 | 58 | Forward Carriage | manual | 1d? | 2012-09-17 | 2012-09-17 |  |  |  |  |  |  |  |
| 68 | 59 | Reinforce Fwd Carriage |  | 3w | 2012-11-12 | 2012-11-30 | 69 | 0d |  | 2013-05-24 | Forrest | 120h | 14264019 |
| 69 | 60 | Weld PCAL and LTCC brackets |  | 3w | 2012-10-22 | 2012-11-09 | 70 | 0d |  | 2013-05-09 | Forrest | 120h | 14264017 |
| 70 | 61 | Install panel 2 TOF brackets | milestone | 0d | 2012-10-19 | 2012-10-19 | 71 | 0d |  | 2013-05-22 | Forrest |  | 14264018 |
| 71 | 62 | Add handrails, stairs, and A/C to level 0 |  | 2w | 2012-10-08 | 2012-10-19 | 72 | 0d |  | 2013-05-24 | Forrest | 80h |  |
| 72 | 63 | Motion system |  | 3w | 2012-09-17 | 2012-10-05 |  | 0d |  | 2013-05-24 | Forrest | 120h |  |
